# DEFENSA RIBEREÑA RIO LARAMARCA

Schedule from Primavera P6, 2023-05-01 to 2024-03-25, data date 2023-03-01.
Must finish by 2024-01-31

## Calendars

- CALENDARIO P6: Mon-Sun 08:00-16:00. Exceptions (off unless hours are given): 2023-07-29 08:00-16:00, 2023-12-09 08:00-16:00.

## Schedule

| ID | WBS | Activity | Type | Duration | Start | Finish | Predecessors | Total float | Free float | Constraint |
| --- | --- | --- | --- | --- | --- | --- | --- | --- | --- | --- |
|  | C | **CONSTRUCCIÓN** |  |  | 2023-05-01 | 2024-03-25 |  |  |  |  |
|  | 70 | **OBRAS EXTERIORES** |  |  | 2023-05-01 | 2024-03-25 |  |  |  |  |
|  | 14 | **REFUERZO RIBERA DE RIO** |  |  | 2023-05-01 | 2024-03-25 |  |  |  |  |
|  | 0 | **INICIO** |  |  | 2023-05-01 | 2023-05-01 |  |  |  |  |
| A4350 |  | INICIO | milestone | 0d | 2023-05-01 | 2023-05-01 |  | -43.5d | 0d | start on or after 2023-05-01 |
|  | 1 | **SUBPROYECTO A2 - INTERVENCIÓN AVENIDA PERÚ** |  |  | 2023-05-01 | 2023-10-10 |  |  |  |  |
|  | 1 | **OBRAS PRELIMINARES** |  |  | 2023-05-01 | 2023-07-10 |  |  |  |  |
| A1000 |  | UBICACIÓN Y DELIMITACIÓN DE LA ZONA DE PLANTACIÓN |  | 2d | 2023-05-01 | 2023-05-02 | A4350 SS | -43.5d | 0d |  |
| A01000 |  | MEJORAMIENTO DE SUELO CON TIERRA VEGETAL |  | 68d | 2023-05-02 | 2023-07-08 | A1000 SS+1d | -43.5d | 0d |  |
| A1010 |  | DESPEDREGADO DEL TERRENO CON MEDIOS MANUALES |  | 68d | 2023-05-03 | 2023-07-09 | A01000 SS+1d | -43.5d | 0d |  |
| A1020 |  | RASTRILLADO DEL TERRENO |  | 68d | 2023-05-04 | 2023-07-10 | A1010 SS+1d | -43.5d | 0d |  |
| A1030 |  | TRAZADO, MARCACIÓN Y ESTACADO |  | 68d | 2023-05-04 | 2023-07-10 | A1020 SS | -43.5d | 0d |  |
| A1040 |  | RETIRO Y ELIMINACIÓN DE RESIDUOS SÓLIDOS |  | 68d | 2023-05-04 | 2023-07-10 | A1010 SS+1d | 204d | 259d |  |
|  | 2 | **ADQUISICION DE PLANTONES (altura al adquirirse)** |  |  | 2023-05-19 | 2023-07-09 |  |  |  |  |
| A1100 |  | SENNA MULTIGLANDULOSA MUTUY (0.60 a 0.80m) |  | 26d | 2023-05-19 | 2023-06-13 | A1030 SS+15d | -43.5d | 0d |  |
| A1110 |  | ENCELIA CANESCEN GIRASOL SILVESTRE (0.20m a 0.30m) |  | 26d | 2023-05-19 | 2023-06-13 | A1100 SS | -43.5d | 0d |  |
| A1050 |  | PROSOPIS PALLIDA KUNTH ALGARROBO (0.80 a 1.50m) |  | 26d | 2023-06-14 | 2023-07-09 | A1110 | -43.5d | 0d |  |
| A1070 |  | ACACIA MACRACANTHA FAIQUE (0.80 a 1.50m) |  | 26d | 2023-06-14 | 2023-07-09 | A1050 SS | 202d | 0d |  |
| A1080 |  | PARKINSONIA ACULEATA AZOTE DE CRISTO (1.00 a 1.50 m) |  | 26d | 2023-06-14 | 2023-07-09 | A1070 SS | 202d | 0d |  |
|  | 3 | **ADQUISICION RECALCE (Se concidera el 5%)** |  |  | 2023-06-14 | 2023-07-10 |  |  |  |  |
| A1180 |  | SENNA MULTIGLANDULOSA MUTUY (0.60 a 0.80m) |  | 1d | 2023-06-14 | 2023-06-14 | A1100 | 230d | 0d |  |
| A1190 |  | ENCELIA CANESCEN GIRASOL SILVESTRE (0.20m a 0.30m) |  | 1d | 2023-06-14 | 2023-06-14 | A1180 SS | 230d | 285d |  |
| A1130 |  | PROSOPIS PALLIDA KUNTH ALGARROBO (0.80 a 1.50m) |  | 1d | 2023-07-10 | 2023-07-10 | A1050 | 204d | 0d |  |
| A1150 |  | ACACIA MACRACANTHA FAIQUE (0.80 a 1.50m) |  | 1d | 2023-07-10 | 2023-07-10 | A1130 SS | 204d | 0d |  |
| A1160 |  | PARKINSONIA ACULEATA AZOTE DE CRISTO (1.00 a 1.50 m) |  | 1d | 2023-07-10 | 2023-07-10 | A1150 SS | 204d | 259d |  |

| ID | WBS | Activity | Duration | Start | Finish | Predecessors | Total float | Free float |
| --- | --- | --- | --- | --- | --- | --- | --- | --- |
|  | 4 | **TRANSPORTE** |  | 2023-05-19 | 2023-07-10 |  |  |  |
| A1210 |  | Flete transporte terrestre para especies vegetales | 53d | 2023-05-19 | 2023-07-10 | A1100 SS | 204d | 259d |
|  | 5 | **ADQUISICION INSUMOS AGRICOLAS Y OTROS** |  | 2023-05-19 | 2023-07-10 |  |  |  |
| A1220 |  | COMPOST SACO 35kg | 53d | 2023-05-19 | 2023-07-10 | A1100 SS | 204d | 0d |
| A1230 |  | AZUFRE SACO 25kg | 53d | 2023-05-19 | 2023-07-10 | A1220 SS | 204d | 0d |
| A1240 |  | YESO SACO 40kg | 53d | 2023-05-19 | 2023-07-10 | A1230 SS | 204d | 0d |
| A1250 |  | NPK 10:30:10 SACO DE 50kg | 53d | 2023-05-19 | 2023-07-10 | A1240 SS | 204d | 0d |
| A1260 |  | NPK 20:20:20 SACO DE 50kg | 53d | 2023-05-19 | 2023-07-10 | A1250 SS | 204d | 0d |
| A1270 |  | TUTORES EUCALIPTO 2.5m | 53d | 2023-05-19 | 2023-07-10 | A1260 SS | 204d | 0d |
| A1280 |  | SOGA DE YUTE 5/64 DE 58m | 53d | 2023-05-19 | 2023-07-10 | A1270 SS | 204d | 0d |
| A1290 |  | PITON CONTRA INCENDIO PARA ADAPTACION DE MANGUERA DE CISTERNA | 3d | 2023-05-19 | 2023-05-21 | A1280 SS | 254d | 309d |
|  | 6 | **INSTALACION DE PLANTONES (Incluye colocacion de sustrato, tierra del lugar,** |  | 2023-05-20 | 2023-07-12 |  |  |  |
| A1350 |  | SENNA MULTIGLANDULOSA MUTUY (0.60 a 0.80m) | 28d | 2023-05-20 | 2023-06-16 | A1100 SS+1d | 228d | 283d |
| A1360 |  | ENCELIA CANESCEN GIRASOL SILVESTRE (0.20m a 0.30m) | 28d | 2023-05-20 | 2023-06-16 | A1110 SS+1d | 228d | 283d |
| A1300 |  | PROSOPIS PALLIDA KUNTH ALGARROBO (0.80 a 1.50m) | 28d | 2023-06-15 | 2023-07-12 | A1050 SS+1d | -43.5d | 0d |
| A1320 |  | ACACIA MACRACANTHA FAIQUE (0.80 a 1.50m) | 28d | 2023-06-15 | 2023-07-12 | A1070 SS+1d | 202d | 257d |
| A1330 |  | PARKINSONIA ACULEATA AZOTE DE CRISTO (1.00 a 1.50 m) | 28d | 2023-06-15 | 2023-07-12 | A1080 SS+1d | 202d | 257d |
|  | 7 | **NSTALACIÓN DE ALCORQUES** |  | 2023-06-15 | 2023-07-12 |  |  |  |
| A1380 |  | ALCORQUES DE PIEDRA DE CANTO RODADO PARA ARBOLES | 27.25d | 2023-06-15 | 2023-07-12 | A1300 SS | -43.5d | 0d |
|  | 8 | **RIEGO DE ESPECIES 12 MESES ( instalacion+establecimiento)** |  | 2023-07-13 | 2023-10-10 |  |  |  |
| A1390 |  | Riego por inundación, mediante camión cisterna con mangera adaptada con piton | 90d | 2023-07-13 | 2023-10-10 | A1300 | 112d | 0d |
|  | 9 | **MANTENIMIENTO PREVENTIVO PARA ESTABLECIMIENTO DE ESPECIE (12** |  | 2023-07-13 | 2023-10-10 |  |  |  |
| A1400 |  | MANO DE OBRA + PODA + REMOCION, DESMALEZADO, RECALCE Y | 90d | 2023-07-13 | 2023-10-10 | A1390 SS | 112d | 167d |
|  | 2 | **SUBPROYECTO A2 - RAMPA DURA** |  | 2023-07-12 | 2023-12-22 |  |  |  |
|  | 1 | **OBRAS PRELIMINARES** |  | 2023-07-12 | 2023-09-21 |  |  |  |
| A3100 |  | UBICACIÓN Y DELIMITACIÓN DE LA ZONA DE PLANTACIÓN | 2d | 2023-07-12 | 2023-07-14 | A1380 | -43.5d | 0d |
| A3090 |  | MEJORAMIENTO DE SUELO CON TIERRA VEGETAL | 68d | 2023-07-13 | 2023-09-19 | A3100 SS+1d | -43.5d | 0d |
| A3110 |  | DESPEDREGADO DEL TERRENO CON MEDIOS MANUALES | 68d | 2023-07-14 | 2023-09-20 | A3090 SS+1d | -43.5d | 0d |
| A3120 |  | RASTRILLADO DEL TERRENO | 68d | 2023-07-15 | 2023-09-21 | A3110 SS+1d | -43.5d | 0d |
| A3130 |  | TRAZADO, MARCACIÓN Y ESTACADO | 68d | 2023-07-15 | 2023-09-21 | A3120 SS | -43.5d | 0d |
| A3140 |  | RETIRO Y ELIMINACIÓN DE RESIDUOS SÓLIDOS | 68d | 2023-07-15 | 2023-09-21 | A3110 SS+1d | 131.75d | 186.75d |

| ID | WBS | Activity | Duration | Start | Finish | Predecessors | Total float | Free float |
| --- | --- | --- | --- | --- | --- | --- | --- | --- |
|  | 2 | **ADQUISICION DE PLANTONES (altura al adquirirse)** |  | 2023-07-30 | 2023-09-20 |  |  |  |
| A3200 |  | SENNA MULTIGLANDULOSA MUTUY (0.60 a 0.80m) | 26d | 2023-07-30 | 2023-08-25 | A3130 SS+15d | -43.5d | 0d |
| A3210 |  | ENCELIA CANESCEN GIRASOL SILVESTRE (0.20m a 0.30m) | 26d | 2023-07-30 | 2023-08-25 | A3200 SS | -43.5d | 0d |
| A3150 |  | PROSOPIS PALLIDA KUNTH ALGARROBO (0.80 a 1.50m) | 26d | 2023-08-25 | 2023-09-20 | A3210 | -43.5d | 0d |
| A3170 |  | ACACIA MACRACANTHA FAIQUE (0.80 a 1.50m) | 26d | 2023-08-25 | 2023-09-20 | A3150 SS | 129.75d | 0d |
| A3180 |  | PARKINSONIA ACULEATA AZOTE DE CRISTO (1.00 a 1.50 m) | 26d | 2023-08-25 | 2023-09-20 | A3170 SS | 129.75d | 0d |
|  | 3 | **ADQUISICION RECALCE (Se concidera el 5%)** |  | 2023-08-25 | 2023-09-21 |  |  |  |
| A3280 |  | SENNA MULTIGLANDULOSA MUTUY (0.60 a 0.80m) | 1d | 2023-08-25 | 2023-08-26 | A3200 | 157.75d | 0d |
| A3290 |  | ENCELIA CANESCEN GIRASOL SILVESTRE (0.20m a 0.30m) | 1d | 2023-08-25 | 2023-08-26 | A3280 SS | 157.75d | 212.75d |
| A3230 |  | PROSOPIS PALLIDA KUNTH ALGARROBO (0.80 a 1.50m) | 1d | 2023-09-20 | 2023-09-21 | A3150 | 131.75d | 0d |
| A3250 |  | ACACIA MACRACANTHA FAIQUE (0.80 a 1.50m) | 1d | 2023-09-20 | 2023-09-21 | A3230 SS | 131.75d | 0d |
| A3260 |  | PARKINSONIA ACULEATA AZOTE DE CRISTO (1.00 a 1.50 m) | 1d | 2023-09-20 | 2023-09-21 | A3250 SS | 131.75d | 186.75d |
|  | 4 | **TRANSPORTE** |  | 2023-07-30 | 2023-09-21 |  |  |  |
| A3310 |  | Flete transporte terrestre para especies vegetales | 53d | 2023-07-30 | 2023-09-21 | A3200 SS | 131.75d | 186.75d |
|  | 5 | **ADQUISICION INSUMOS AGRICOLAS Y OTROS** |  | 2023-07-30 | 2023-09-21 |  |  |  |
| A3320 |  | COMPOST SACO 35kg | 53d | 2023-07-30 | 2023-09-21 | A3200 SS | 131.75d | 0d |
| A3330 |  | AZUFRE SACO 25kg | 53d | 2023-07-30 | 2023-09-21 | A3320 SS | 131.75d | 0d |
| A3340 |  | YESO SACO 40kg | 53d | 2023-07-30 | 2023-09-21 | A3330 SS | 131.75d | 0d |
| A3350 |  | NPK 10:30:10 SACO DE 50kg | 53d | 2023-07-30 | 2023-09-21 | A3340 SS | 131.75d | 0d |
| A3360 |  | NPK 20:20:20 SACO DE 50kg | 53d | 2023-07-30 | 2023-09-21 | A3350 SS | 131.75d | 0d |
| A3370 |  | TUTORES EUCALIPTO 2.5m | 53d | 2023-07-30 | 2023-09-21 | A3360 SS | 131.75d | 0d |
| A3380 |  | SOGA DE YUTE 5/64 DE 58m | 53d | 2023-07-30 | 2023-09-21 | A3370 SS | 131.75d | 0d |
| A3390 |  | PITON CONTRA INCENDIO PARA ADAPTACION DE MANGUERA DE CISTERNA | 3d | 2023-07-30 | 2023-08-02 | A3380 SS | 181.75d | 236.75d |
|  | 6 | **INSTALACION DE PLANTONES (Incluye colocacion de sustrato, tierra del lugar,** |  | 2023-07-31 | 2023-09-23 |  |  |  |
| A3450 |  | SENNA MULTIGLANDULOSA MUTUY (0.60 a 0.80m) | 28d | 2023-07-31 | 2023-08-28 | A3200 SS+1d | 155.75d | 210.75d |
| A3460 |  | ENCELIA CANESCEN GIRASOL SILVESTRE (0.20m a 0.30m) | 28d | 2023-07-31 | 2023-08-28 | A3210 SS+1d | 155.75d | 210.75d |
| A3400 |  | PROSOPIS PALLIDA KUNTH ALGARROBO (0.80 a 1.50m) | 28d | 2023-08-26 | 2023-09-23 | A3150 SS+1d | -43.5d | 0d |
| A3420 |  | ACACIA MACRACANTHA FAIQUE (0.80 a 1.50m) | 28d | 2023-08-26 | 2023-09-23 | A3170 SS+1d | 129.75d | 184.75d |
| A3430 |  | PARKINSONIA ACULEATA AZOTE DE CRISTO (1.00 a 1.50 m) | 28d | 2023-08-26 | 2023-09-23 | A3180 SS+1d | 129.75d | 184.75d |

| ID | WBS | Activity | Duration | Start | Finish | Predecessors | Total float | Free float |
| --- | --- | --- | --- | --- | --- | --- | --- | --- |
|  | 7 | **NSTALACIÓN DE ALCORQUES** |  | 2023-08-26 | 2023-09-22 |  |  |  |
| A3480 |  | ALCORQUES DE PIEDRA DE CANTO RODADO PARA ARBOLES | 27.25d | 2023-08-26 | 2023-09-22 | A3400 SS | -43.5d | 0d |
|  | 8 | **RIEGO DE ESPECIES 12 MESES ( instalacion+establecimiento)** |  | 2023-09-23 | 2023-12-22 |  |  |  |
| A3490 |  | Riego por inundación, mediante camión cisterna con mangera adaptada con piton | 90d | 2023-09-23 | 2023-12-22 | A3400 | 39.75d | 0d |
|  | 9 | **MANTENIMIENTO PREVENTIVO PARA ESTABLECIMIENTO DE ESPECIE (12** |  | 2023-09-23 | 2023-12-22 |  |  |  |
| A3500 |  | MANO DE OBRA + PODA + REMOCION, DESMALEZADO, RECALCE Y | 90d | 2023-09-23 | 2023-12-22 | A3490 SS | 39.75d | 94.75d |
|  | 3 | **SUBPROYECTO A2 - TANGAY** |  | 2023-09-22 | 2024-01-01 |  |  |  |
|  | 1 | **OBRAS PRELIMINARES** |  | 2023-09-22 | 2023-09-30 |  |  |  |
| A3930 |  | MEJORAMIENTO DE SUELO CON TIERRA VEGETAL | 7d | 2023-09-22 | 2023-09-29 | A3940 SS | -43.5d | 0d |
| A3940 |  | UBICACIÓN Y DELIMITACIÓN DE LA ZONA DE PLANTACIÓN | 1d | 2023-09-22 | 2023-09-23 | A3480 | -43.5d | 0d |
| A3950 |  | DESPEDREGADO DEL TERRENO CON MEDIOS MANUALES | 7d | 2023-09-22 | 2023-09-29 | A3930 SS | -43.5d | 0d |
| A3960 |  | RASTRILLADO DEL TERRENO | 7d | 2023-09-22 | 2023-09-29 | A3950 SS | -43.5d | 0d |
| A3970 |  | TRAZADO, MARCACIÓN Y ESTACADO | 7d | 2023-09-22 | 2023-09-29 | A3960 SS | -43.5d | 0d |
| A3980 |  | RETIRO Y ELIMINACIÓN DE RESIDUOS SÓLIDOS | 7d | 2023-09-23 | 2023-09-30 | A3950 SS+1d | 122.5d | 177.5d |
|  | 2 | **ADQUISICION DE PLANTONES (altura al adquirirse)** |  | 2023-09-24 | 2023-10-02 |  |  |  |
| A4040 |  | SENNA MULTIGLANDULOSA MUTUY (0.60 a 0.80m) | 4d | 2023-09-24 | 2023-09-28 | A3970 SS+2d | -43.5d | 0d |
| A4050 |  | ENCELIA CANESCEN GIRASOL SILVESTRE (0.20m a 0.30m) | 4d | 2023-09-24 | 2023-09-28 | A4040 SS | -43.5d | 0d |
| A4010 |  | ACACIA MACRACANTHA FAIQUE (0.80 a 1.50m) | 4d | 2023-09-28 | 2023-10-02 | A4050 | -43.5d | 0d |
| A4020 |  | PARKINSONIA ACULEATA AZOTE DE CRISTO (1.00 a 1.50 m) | 4d | 2023-09-28 | 2023-10-02 | A4010 SS | 119.5d | 0d |
|  | 3 | **ADQUISICION RECALCE (Se concidera el 5%)** |  | 2023-09-28 | 2023-09-29 |  |  |  |
| A4090 |  | ACACIA MACRACANTHA FAIQUE (0.80 a 1.50m) | 1d | 2023-09-28 | 2023-09-29 | A4010 SS | 123.5d | 0d |
| A4100 |  | PARKINSONIA ACULEATA AZOTE DE CRISTO (1.00 a 1.50 m) | 1d | 2023-09-28 | 2023-09-29 | A4090 SS | 123.5d | 178.5d |
| A4120 |  | SENNA MULTIGLANDULOSA MUTUY (0.60 a 0.80m) | 1d | 2023-09-28 | 2023-09-29 | A4040 | 123.5d | 0d |
| A4130 |  | ENCELIA CANESCEN GIRASOL SILVESTRE (0.20m a 0.30m) | 1d | 2023-09-28 | 2023-09-29 | A4120 SS | 123.5d | 178.5d |

| ID | WBS | Activity | Duration | Start | Finish | Predecessors | Total float | Free float | Constraint |
| --- | --- | --- | --- | --- | --- | --- | --- | --- | --- |
|  | 4 | **TRANSPORTE** |  | 2023-09-24 | 2023-10-03 |  |  |  |  |
| A4150 |  | Flete transporte terrestre para especies vegetales | 9d | 2023-09-24 | 2023-10-03 | A4040 SS | 119.5d | 174.5d |  |
|  | 5 | **ADQUISICION INSUMOS AGRICOLAS Y OTROS** |  | 2023-09-24 | 2023-10-03 |  |  |  |  |
| A4160 |  | COMPOST SACO 35kg | 9d | 2023-09-24 | 2023-10-03 | A4040 SS | 119.5d | 0d |  |
| A4170 |  | AZUFRE SACO 25kg | 9d | 2023-09-24 | 2023-10-03 | A4160 SS | 119.5d | 0d |  |
| A4180 |  | YESO SACO 40kg | 9d | 2023-09-24 | 2023-10-03 | A4170 SS | 119.5d | 0d |  |
| A4190 |  | NPK 10:30:10 SACO DE 50kg | 9d | 2023-09-24 | 2023-10-03 | A4180 SS | 119.5d | 0d |  |
| A4200 |  | NPK 20:20:20 SACO DE 50kg | 9d | 2023-09-24 | 2023-10-03 | A4190 SS | 119.5d | 0d |  |
| A4210 |  | TUTORES EUCALIPTO 2.5m | 9d | 2023-09-24 | 2023-10-03 | A4200 SS | 119.5d | 0d |  |
| A4220 |  | SOGA DE YUTE 5/64 DE 58m | 9d | 2023-09-24 | 2023-10-03 | A4210 SS | 119.5d | 0d |  |
| A4230 |  | PITON CONTRA INCENDIO PARA ADAPTACION DE MANGUERA DE CISTERNA | 9d | 2023-09-24 | 2023-10-03 | A4220 SS | 119.5d | 174.5d |  |
|  | 6 | **INSTALACION DE PLANTONES (Incluye colocacion de sustrato, tierra del lugar,** |  | 2023-09-25 | 2023-10-03 |  |  |  |  |
| A4290 |  | SENNA MULTIGLANDULOSA MUTUY (0.60 a 0.80m) | 4d | 2023-09-25 | 2023-09-29 | A4040 SS+1d | 123.5d | 178.5d |  |
| A4300 |  | ENCELIA CANESCEN GIRASOL SILVESTRE (0.20m a 0.30m) | 4d | 2023-09-25 | 2023-09-29 | A4050 SS+1d | 123.5d | 178.5d |  |
| A4260 |  | ACACIA MACRACANTHA FAIQUE (0.80 a 1.50m) | 4d | 2023-09-29 | 2023-10-03 | A4010 SS+1d | -43.5d | 0d |  |
| A4270 |  | PARKINSONIA ACULEATA AZOTE DE CRISTO (1.00 a 1.50 m) | 4d | 2023-09-29 | 2023-10-03 | A4020 SS+1d | 119.5d | 174.5d |  |
|  | 7 | **NSTALACIÓN DE ALCORQUES** |  | 2023-09-29 | 2023-10-03 |  |  |  |  |
| A4320 |  | ALCORQUES DE PIEDRA DE CANTO RODADO PARA ARBOLES | 4d | 2023-09-29 | 2023-10-03 | A4260 SS | -43.5d | 0d |  |
|  | 8 | **RIEGO DE ESPECIES 12 MESES ( instalacion+establecimiento)** |  | 2023-10-03 | 2024-01-01 |  |  |  |  |
| A4330 |  | Riego por inundación, mediante camión cisterna con mangera adaptada con piton | 90d | 2023-10-03 | 2024-01-01 | A4260 | 29.5d | 0d |  |
|  | 9 | **MANTENIMIENTO PREVENTIVO PARA ESTABLECIMIENTO DE ESPECIE (12** |  | 2023-10-03 | 2024-01-01 |  |  |  |  |
| A4340 |  | MANO DE OBRA + PODA + REMOCION, DESMALEZADO, RECALCE Y | 90d | 2023-10-03 | 2024-01-01 | A4330 SS | 29.5d | 84.5d |  |
|  | 4 | **SUBPROYECTO A1 - HUMEDAL VILLA MARIA MARGEN IZQUIERDO** |  | 2023-05-01 | 2024-01-31 |  |  |  |  |
|  | 1 | **OBRAS PRELIMINARES** |  | 2023-05-01 | 2023-12-13 |  |  |  |  |
| A2020 |  | UBICACIÓN Y DELIMITACIÓN DE LA ZONA DE PLANTACIÓN | 10d | 2023-05-01 | 2023-05-10 |  | -1d | 0d | start on or after 2023-05-01 |
| A2030 |  | DESPEDREGADO DEL TERRENO CON MEDIOS MANUALES | 220d | 2023-05-04 | 2023-12-09 | A2020 SS+3d | -1d | 0d |  |
| A2040 |  | RASTRILLADO DEL TERRENO | 220d | 2023-05-07 | 2023-12-12 | A2030 SS+3d | -1d | 0d |  |
| A2060 |  | RETIRO Y ELIMINACIÓN DE RESIDUOS SÓLIDOS | 220d | 2023-05-07 | 2023-12-12 | A2030 SS+3d | 49d | 104d |  |
| A2050 |  | TRAZADO, MARCACIÓN Y ESTACADO | 220d | 2023-05-08 | 2023-12-13 | A2040 SS+1d | -1d | 0d |  |

| ID | WBS | Activity | Duration | Start | Finish | Predecessors | Total float | Free float |
| --- | --- | --- | --- | --- | --- | --- | --- | --- |
|  | 2 | **ADQUISICION DE PLANTONES (altura al adquirirse)** |  | 2023-05-08 | 2023-10-24 |  |  |  |
| A2650 |  | ENCELIA CANESCEN GIRASOL SILVESTRE (0.20m a 0.30m) | 85d | 2023-05-08 | 2023-07-31 | A2050 SS | -1d | 0d |
| A2660 |  | PHYLA NODIFLORA LIPPIA (h:0.15m) | 85d | 2023-05-08 | 2023-07-31 | A2650 SS | -1d | 0d |
| A2670 |  | SESUVIUM PORTULACASTRUM PORTULACA (h:0.15m) | 85d | 2023-05-08 | 2023-07-31 | A2660 SS | -1d | 0d |
| A2680 |  | SCIRPUS CALIFORNICUS ENEA (h:0.50m) | 85d | 2023-05-08 | 2023-07-31 | A2670 SS | -1d | 0d |
| A2690 |  | SCIRPUS CONGLOMERATUS JUNCO (h:0.50m) | 85d | 2023-05-08 | 2023-07-31 | A2680 SS | -1d | 0d |
| A2580 |  | PROSOPIS PALLIDA KUNTH ALGARROBO (0.80 a 1.50m) | 85d | 2023-08-01 | 2023-10-24 | A2690 | -1d | 0d |
| A2600 |  | ACACIA MACRACANTHA FAIQUE (0.80 a 1.50m) | 85d | 2023-08-01 | 2023-10-24 | A2580 SS | -1d | 0d |
| A2610 |  | PARKINSONIA ACULEATA AZOTE DE CRISTO (1.00 a 1.50 m) | 85d | 2023-08-01 | 2023-10-24 | A2600 SS | -1d | 0d |
| A2620 |  | TESSARIA INTEGRIFOLIA RUIZ & PAV PAJARRO BOBO (0.80 a 1.50m) | 85d | 2023-08-01 | 2023-10-24 | A2610 SS | -1d | 0d |
| A2630 |  | BACCHARIS SALICIFOLIA CHILCA (h:080 a 1.50m) | 85d | 2023-08-01 | 2023-10-24 | A2620 SS | -1d | 0d |
|  | 3 | **ADQUISICION RECALCE (Se concidera el 5%)** |  | 2023-08-01 | 2023-10-29 |  |  |  |
| A2780 |  | ENCELIA CANESCEN GIRASOL SILVESTRE (0.20m a 0.30m) | 5d | 2023-08-01 | 2023-08-05 | A2650 | 178d | 233d |
| A2790 |  | PHYLA NODIFLORA LIPPIA (h:0.15m) | 5d | 2023-08-01 | 2023-08-05 | A2660 | 178d | 233d |
| A2800 |  | SESUVIUM PORTULACASTRUM PORTULACA (h:0.15m) | 5d | 2023-08-01 | 2023-08-05 | A2670 | 178d | 233d |
| A2810 |  | SCIRPUS CALIFORNICUS ENEA (h:0.50m) | 5d | 2023-08-01 | 2023-08-05 | A2680 | 178d | 233d |
| A2820 |  | SCIRPUS CONGLOMERATUS JUNCO (h:0.50m) | 5d | 2023-08-01 | 2023-08-05 | A2690 | 178d | 233d |
| A2710 |  | PROSOPIS PALLIDA KUNTH ALGARROBO (0.80 a 1.50m) | 5d | 2023-10-25 | 2023-10-29 | A2580 | 93d | 148d |
| A2730 |  | ACACIA MACRACANTHA FAIQUE (0.80 a 1.50m) | 5d | 2023-10-25 | 2023-10-29 | A2600 | 93d | 148d |
| A2740 |  | PARKINSONIA ACULEATA AZOTE DE CRISTO (1.00 a 1.50 m) | 5d | 2023-10-25 | 2023-10-29 | A2610 | 93d | 148d |
| A2750 |  | TESSARIA INTEGRIFOLIA RUIZ & PAV PAJARRO BOBO (0.80 a 1.50m) | 5d | 2023-10-25 | 2023-10-29 | A2620 | 93d | 148d |
| A2760 |  | BACCHARIS SALICIFOLIA CHILCA (h:080 a 1.50m) | 5d | 2023-10-25 | 2023-10-29 | A2630 | 93d | 148d |
|  | 4 | **TRANSPORTE** |  | 2023-05-08 | 2023-10-29 |  |  |  |
| A2840 |  | Flete transporte terrestre para especies vegetales | 175d | 2023-05-08 | 2023-10-29 | A2650 SS | 93d | 148d |

| ID | WBS | Activity | Duration | Start | Finish | Predecessors | Total float | Free float |
| --- | --- | --- | --- | --- | --- | --- | --- | --- |
|  | 5 | **ADQUISICION INSUMOS AGRICOLAS Y OTROS** |  | 2023-05-08 | 2023-10-29 |  |  |  |
| A2850 |  | COMPOST SACO 35kg | 175d | 2023-05-08 | 2023-10-29 | A2650 SS | 93d | 0d |
| A2860 |  | AZUFRE SACO 25kg | 175d | 2023-05-08 | 2023-10-29 | A2850 SS | 93d | 0d |
| A2870 |  | YESO SACO 40kg | 175d | 2023-05-08 | 2023-10-29 | A2860 SS | 93d | 0d |
| A2880 |  | NPK 10:30:10 SACO DE 50kg | 175d | 2023-05-08 | 2023-10-29 | A2870 SS | 93d | 0d |
| A2890 |  | NPK 20:20:20 SACO DE 50kg | 175d | 2023-05-08 | 2023-10-29 | A2880 SS | 93d | 0d |
| A2900 |  | TUTORES EUCALIPTO 2.5m | 175d | 2023-05-08 | 2023-10-29 | A2890 SS | 93d | 0d |
| A2910 |  | SOGA DE YUTE 5/64 DE 58m | 175d | 2023-05-08 | 2023-10-29 | A2900 SS | 93d | 0d |
| A2920 |  | PITON CONTRA INCENDIO PARA ADAPTACION DE MANGUERA DE CISTERNA | 3d | 2023-05-08 | 2023-05-10 | A2910 SS | 265d | 320d |
|  | 6 | **INSTALACION DE PLANTONES (Incluye colocacion de sustrato, tierra del lugar,** |  | 2023-05-08 | 2023-11-02 |  |  |  |
| A3000 |  | ENCELIA CANESCEN GIRASOL SILVESTRE (0.20m a 0.30m) | 90d | 2023-05-08 | 2023-08-05 | A2650 SS | 178d | 233d |
| A3010 |  | PHYLA NODIFLORA LIPPIA (h:0.15m) | 90d | 2023-05-08 | 2023-08-05 | A2660 SS | 178d | 233d |
| A3020 |  | SESUVIUM PORTULACASTRUM PORTULACA (h:0.15m) | 90d | 2023-05-08 | 2023-08-05 | A2670 SS | 178d | 233d |
| A3030 |  | SCIRPUS CALIFORNICUS ENEA (h:0.50m) | 90d | 2023-05-08 | 2023-08-05 | A2680 SS | 178d | 233d |
| A3040 |  | SCIRPUS CONGLOMERATUS JUNCO (h:0.50m) | 90d | 2023-05-08 | 2023-08-05 | A2690 SS | 178d | 233d |
| A2930 |  | PROSOPIS PALLIDA KUNTH ALGARROBO (0.80 a 1.50m) | 90d | 2023-08-05 | 2023-11-02 | A2580 SS+4d | 89d | 0d |
| A2950 |  | ACACIA MACRACANTHA FAIQUE (0.80 a 1.50m) | 90d | 2023-08-05 | 2023-11-02 | A2600 SS+4d | 89d | 144d |
| A2960 |  | PARKINSONIA ACULEATA AZOTE DE CRISTO (1.00 a 1.50 m) | 90d | 2023-08-05 | 2023-11-02 | A2610 SS+4d | 89d | 144d |
| A2970 |  | TESSARIA INTEGRIFOLIA RUIZ & PAV PAJARRO BOBO (0.80 a 1.50m) | 90d | 2023-08-05 | 2023-11-02 | A2620 SS+4d | 89d | 144d |
| A2980 |  | BACCHARIS SALICIFOLIA CHILCA (h:080 a 1.50m) | 90d | 2023-08-05 | 2023-11-02 | A2630 SS+4d | -1d | 0d |
|  | 7 | **NSTALACIÓN DE ALCORQUES** |  | 2023-08-05 | 2023-11-02 |  |  |  |
| A3060 |  | ALCORQUES DE PIEDRA DE CANTO RODADO PARA ARBOLES | 90d | 2023-08-05 | 2023-11-02 | A2930 SS | 89d | 144d |
|  | 8 | **RIEGO DE ESPECIES 12 MESES ( instalacion+establecimiento)** |  | 2023-11-03 | 2024-01-31 |  |  |  |
| A3070 |  | Riego por inundación, mediante camión cisterna con mangera adaptada con piton | 90d | 2023-11-03 | 2024-01-31 | A2980 | -1d | 0d |

| ID | WBS | Activity | Duration | Start | Finish | Predecessors | Total float | Free float | Constraint |
| --- | --- | --- | --- | --- | --- | --- | --- | --- | --- |
|  | 9 | **MANTENIMIENTO PREVENTIVO PARA ESTABLECIMIENTO DE ESPECIE (12** |  | 2023-11-03 | 2024-01-31 |  |  |  |  |
| A3080 |  | MANO DE OBRA + PODA + REMOCION, DESMALEZADO, RECALCE Y | 90d | 2023-11-03 | 2024-01-31 | A3070 SS | -1d | 54d |  |
|  | 5 | **SUBPROYECTO A1 - HUMEDAL VILLA MARIA MARGEN DERECHO** |  | 2023-05-01 | 2024-03-25 |  |  |  |  |
|  | 1 | **OBRAS PRELIMINARES** |  | 2023-05-01 | 2023-12-13 |  |  |  |  |
| A1410 |  | UBICACIÓN Y DELIMITACIÓN DE LA ZONA DE PLANTACIÓN | 7d | 2023-05-01 | 2023-05-07 |  | -55d | 0d | start on or after 2023-05-01 |
| A1430 |  | DESPEDREGADO DEL TERRENO CON MEDIOS MANUALES | 220d | 2023-05-04 | 2023-12-09 | A1410 SS+3d | -55d | 0d |  |
| A1440 |  | RASTRILLADO DEL TERRENO | 220d | 2023-05-07 | 2023-12-12 | A1430 SS+3d | -55d | 0d |  |
| A1460 |  | RETIRO Y ELIMINACIÓN DE RESIDUOS SÓLIDOS | 220d | 2023-05-07 | 2023-12-12 | A1430 SS+3d | 49d | 104d |  |
| A1450 |  | TRAZADO, MARCACIÓN Y ESTACADO | 220d | 2023-05-08 | 2023-12-13 | A1440 SS+1d | -55d | 0d |  |
|  | 2 | **ADQUISICION DE PLANTONES (altura al adquirirse)** |  | 2023-06-28 | 2023-12-14 |  |  |  |  |
| A1560 |  | BATIS MARITIMA VIDRIO (H:0.15m) | 85d | 2023-06-28 | 2023-09-20 | A1450 SS+51d | -55d | 0d |  |
| A1570 |  | ENCELIA CANESCEN GIRASOL SILVESTRE (0.20m a 0.30m) | 85d | 2023-06-28 | 2023-09-20 | A1560 SS | -55d | 0d |  |
| A1580 |  | PHYLA NODIFLORA LIPPIA (h:0.15m) | 85d | 2023-06-28 | 2023-09-20 | A1570 SS | -55d | 0d |  |
| A1590 |  | SESUVIUM PORTULACASTRUM PORTULACA (h:0.15m) | 85d | 2023-06-28 | 2023-09-20 | A1580 SS | -55d | 0d |  |
| A1600 |  | SCIRPUS CALIFORNICUS ENEA (h:0.50m) | 85d | 2023-06-28 | 2023-09-20 | A1590 SS | -55d | 0d |  |
| A1610 |  | SCIRPUS CONGLOMERATUS JUNCO (h:0.50m) | 85d | 2023-06-28 | 2023-09-20 | A1600 SS | -55d | 0d |  |
| A1620 |  | PASPALUM VAGINATUM GRAMA DE AGUA (h:0.15m) | 85d | 2023-06-28 | 2023-09-20 | A1610 SS | -55d | 0d |  |
| A1470 |  | PROSOPIS PALLIDA KUNTH ALGARROBO (0.80 a 1.50m) | 85d | 2023-09-21 | 2023-12-14 | A1620 | -55d | 0d |  |
| A1490 |  | ACACIA MACRACANTHA FAIQUE (0.80 a 1.50m) | 85d | 2023-09-21 | 2023-12-14 | A1470 SS | -55d | 0d |  |
| A1500 |  | PARKINSONIA ACULEATA AZOTE DE CRISTO (1.00 a 1.50 m) | 85d | 2023-09-21 | 2023-12-14 | A1490 SS | -55d | 0d |  |
| A1510 |  | TESSARIA INTEGRIFOLIA RUIZ & PAV PAJARRO BOBO (0.80 a 1.50m) | 85d | 2023-09-21 | 2023-12-14 | A1500 SS | -55d | 0d |  |
| A1550 |  | BACCHARIS SALICIFOLIA CHILCA (h:080 a 1.50m) | 85d | 2023-09-21 | 2023-12-14 | A1510 SS | -55d | 0d |  |
|  | 3 | **ADQUISICION RECALCE (Se concidera el 5%)** |  | 2023-09-21 | 2023-12-19 |  |  |  |  |
| A1690 |  | BATIS MARITIMA VIDRIO (H:0.15m) | 5d | 2023-09-21 | 2023-09-25 | A1560 | 127d | 182d |  |
| A1700 |  | ENCELIA CANESCEN GIRASOL SILVESTRE (0.20m a 0.30m) | 5d | 2023-09-21 | 2023-09-25 | A1570 | 127d | 182d |  |
| A1710 |  | PHYLA NODIFLORA LIPPIA (h:0.15m) | 5d | 2023-09-21 | 2023-09-25 | A1580 | 127d | 182d |  |
| A1720 |  | SESUVIUM PORTULACASTRUM PORTULACA (h:0.15m) | 5d | 2023-09-21 | 2023-09-25 | A1590 | 127d | 182d |  |
| A1730 |  | SCIRPUS CALIFORNICUS ENEA (h:0.50m) | 5d | 2023-09-21 | 2023-09-25 | A1600 | 127d | 182d |  |
| A1740 |  | SCIRPUS CONGLOMERATUS JUNCO (h:0.50m) | 5d | 2023-09-21 | 2023-09-25 | A1610 | 127d | 182d |  |
| A1750 |  | PASPALUM VAGINATUM GRAMA DE AGUA (h:0.15m) | 5d | 2023-09-21 | 2023-09-25 | A1620 | 127d | 182d |  |
| A1630 |  | PROSOPIS PALLIDA KUNTH ALGARROBO (0.80 a 1.50m) | 5d | 2023-12-15 | 2023-12-19 | A1470 | 42d | 97d |  |
| A1650 |  | ACACIA MACRACANTHA FAIQUE (0.80 a 1.50m) | 5d | 2023-12-15 | 2023-12-19 | A1490 | 42d | 97d |  |
| A1660 |  | PARKINSONIA ACULEATA AZOTE DE CRISTO (1.00 a 1.50 m) | 5d | 2023-12-15 | 2023-12-19 | A1500 | 42d | 97d |  |
| A1670 |  | TESSARIA INTEGRIFOLIA RUIZ & PAV PAJARRO BOBO (0.80 a 1.50m) | 5d | 2023-12-15 | 2023-12-19 | A1510 | 42d | 97d |  |
| A1680 |  | BACCHARIS SALICIFOLIA CHILCA (h:080 a 1.50m) | 5d | 2023-12-15 | 2023-12-19 | A1550 | 42d | 97d |  |

| ID | WBS | Activity | Duration | Start | Finish | Predecessors | Total float | Free float |
| --- | --- | --- | --- | --- | --- | --- | --- | --- |
|  | 4 | **TRANSPORTE** |  | 2023-06-28 | 2023-12-19 |  |  |  |
| A1760 |  | Flete transporte terrestre para especies vegetales | 175d | 2023-06-28 | 2023-12-19 | A1560 SS | 42d | 97d |
|  | 5 | **ADQUISICION INSUMOS AGRICOLAS Y OTROS** |  | 2023-06-28 | 2023-12-19 |  |  |  |
| A1770 |  | COMPOST SACO 35kg | 175d | 2023-06-28 | 2023-12-19 | A1560 SS | 42d | 0d |
| A1780 |  | AZUFRE SACO 25kg | 175d | 2023-06-28 | 2023-12-19 | A1770 SS | 42d | 0d |
| A1790 |  | YESO SACO 40kg | 175d | 2023-06-28 | 2023-12-19 | A1780 SS | 42d | 0d |
| A1800 |  | NPK 10:30:10 SACO DE 50kg | 175d | 2023-06-28 | 2023-12-19 | A1790 SS | 42d | 0d |
| A1810 |  | NPK 20:20:20 SACO DE 50kg | 175d | 2023-06-28 | 2023-12-19 | A1800 SS | 42d | 0d |
| A1820 |  | TUTORES EUCALIPTO 2.5m | 175d | 2023-06-28 | 2023-12-19 | A1810 SS | 42d | 0d |
| A1830 |  | SOGA DE YUTE 5/64 DE 58m | 175d | 2023-06-28 | 2023-12-19 | A1820 SS | 42d | 0d |
| A1840 |  | PITON CONTRA INCENDIO PARA ADAPTACION DE MANGUERA DE CISTERNA | 3d | 2023-06-28 | 2023-06-30 | A1830 SS | 214d | 269d |
|  | 6 | **INSTALACION DE PLANTONES (Incluye colocacion de sustrato, tierra del lugar,** |  | 2023-06-28 | 2023-12-23 |  |  |  |
| A1910 |  | BATIS MARITIMA VIDRIO (H:0.15m) | 90d | 2023-06-28 | 2023-09-25 | A1560 SS | 127d | 182d |
| A1920 |  | ENCELIA CANESCEN GIRASOL SILVESTRE (0.20m a 0.30m) | 90d | 2023-06-28 | 2023-09-25 | A1570 SS | 127d | 182d |
| A1930 |  | PHYLA NODIFLORA LIPPIA (h:0.15m) | 90d | 2023-06-28 | 2023-09-25 | A1580 SS | 127d | 182d |
| A1940 |  | SESUVIUM PORTULACASTRUM PORTULACA (h:0.15m) | 90d | 2023-06-28 | 2023-09-25 | A1590 SS | 127d | 182d |
| A1950 |  | SCIRPUS CALIFORNICUS ENEA (h:0.50m) | 90d | 2023-06-28 | 2023-09-25 | A1600 SS | 127d | 182d |
| A1960 |  | SCIRPUS CONGLOMERATUS JUNCO (h:0.50m) | 90d | 2023-06-28 | 2023-09-25 | A1610 SS | 127d | 182d |
| A1970 |  | PASPALUM VAGINATUM GRAMA DE AGUA (h:0.15m) | 90d | 2023-06-28 | 2023-09-25 | A1620 SS | 127d | 182d |
| A1850 |  | PROSOPIS PALLIDA KUNTH ALGARROBO (0.80 a 1.50m) | 90d | 2023-09-25 | 2023-12-23 | A1470 SS+4d | 38d | 0d |
| A1870 |  | ACACIA MACRACANTHA FAIQUE (0.80 a 1.50m) | 90d | 2023-09-25 | 2023-12-23 | A1490 SS+4d | 38d | 93d |
| A1880 |  | PARKINSONIA ACULEATA AZOTE DE CRISTO (1.00 a 1.50 m) | 90d | 2023-09-25 | 2023-12-23 | A1500 SS+4d | 38d | 93d |
| A1890 |  | TESSARIA INTEGRIFOLIA RUIZ & PAV PAJARRO BOBO (0.80 a 1.50m) | 90d | 2023-09-25 | 2023-12-23 | A1510 SS+4d | 38d | 93d |
| A1900 |  | BACCHARIS SALICIFOLIA CHILCA (h:080 a 1.50m) | 90d | 2023-09-25 | 2023-12-23 | A1550 SS+4d | -55d | 0d |

| ID | WBS | Activity | Duration | Start | Finish | Predecessors | Total float | Free float |
| --- | --- | --- | --- | --- | --- | --- | --- | --- |
|  | 7 | **INSTALACIÓN DE ALCORQUES** |  | 2023-09-25 | 2023-12-23 |  |  |  |
| A1980 |  | ALCORQUES DE PIEDRA DE CANTO RODADO PARA ARBOLES | 89.25d | 2023-09-25 | 2023-12-23 | A1850 SS | 38.75d | 93.75d |
|  | 8 | **RIEGO DE ESPECIES 12 MESES ( instalacion+establecimiento)** |  | 2023-12-24 | 2024-03-25 |  |  |  |
| A1990 |  | Riego por inundación, mediante camión cisterna con mangera adaptada con piton | 93d | 2023-12-24 | 2024-03-25 | A1900 | -55d | 0d |
|  | 9 | **MANTENIMIENTO PREVENTIVO PARA ESTABLECIMIENTO DE ESPECIE (12** |  | 2023-12-24 | 2024-03-25 |  |  |  |
| A2000 |  | MANO DE OBRA + PODA + REMOCION, DESMALEZADO, RECALCE Y | 93d | 2023-12-24 | 2024-03-25 | A1990 SS | -55d | 0d |
|  | 6 | **SUBPROYECTO A3 - PUENTE CHACHAPOYAS** |  | 2023-10-03 | 2024-03-14 |  |  |  |
|  | 1 | **OBRAS PRELIMINARES** |  | 2023-10-03 | 2023-12-13 |  |  |  |
| A3520 |  | UBICACIÓN Y DELIMITACIÓN DE LA ZONA DE PLANTACIÓN | 2d | 2023-10-03 | 2023-10-05 | A4320 | -43.5d | 0d |
| A3510 |  | MEJORAMIENTO DE SUELO CON TIERRA VEGETAL | 68d | 2023-10-04 | 2023-12-11 | A3520 SS+1d | -43.5d | 0d |
| A3530 |  | DESPEDREGADO DEL TERRENO CON MEDIOS MANUALES | 68d | 2023-10-05 | 2023-12-12 | A3510 SS+1d | -43.5d | 0d |
| A3540 |  | RASTRILLADO DEL TERRENO | 68d | 2023-10-06 | 2023-12-13 | A3530 SS+1d | -43.5d | 0d |
| A3550 |  | TRAZADO, MARCACIÓN Y ESTACADO | 68d | 2023-10-06 | 2023-12-13 | A3540 SS | -43.5d | 0d |
| A3560 |  | RETIRO Y ELIMINACIÓN DE RESIDUOS SÓLIDOS | 68d | 2023-10-06 | 2023-12-13 | A3530 SS+1d | 48.5d | 103.5d |
|  | 2 | **ADQUISICION DE PLANTONES (altura al adquirirse)** |  | 2023-10-21 | 2023-12-12 |  |  |  |
| A3620 |  | SENNA MULTIGLANDULOSA MUTUY (0.60 a 0.80m) | 26d | 2023-10-21 | 2023-11-16 | A3550 SS+15d | -43.5d | 0d |
| A3630 |  | ENCELIA CANESCEN GIRASOL SILVESTRE (0.20m a 0.30m) | 26d | 2023-10-21 | 2023-11-16 | A3620 SS | -43.5d | 0d |
| A3570 |  | PROSOPIS PALLIDA KUNTH ALGARROBO (0.80 a 1.50m) | 26d | 2023-11-16 | 2023-12-12 | A3630 | -43.5d | 0d |
| A3590 |  | ACACIA MACRACANTHA FAIQUE (0.80 a 1.50m) | 26d | 2023-11-16 | 2023-12-12 | A3570 SS | 46.5d | 0d |
| A3600 |  | PARKINSONIA ACULEATA AZOTE DE CRISTO (1.00 a 1.50 m) | 26d | 2023-11-16 | 2023-12-12 | A3590 SS | 46.5d | 0d |
|  | 3 | **ADQUISICION RECALCE (Se concidera el 5%)** |  | 2023-11-16 | 2023-12-13 |  |  |  |
| A3700 |  | SENNA MULTIGLANDULOSA MUTUY (0.60 a 0.80m) | 1d | 2023-11-16 | 2023-11-17 | A3620 | 74.5d | 0d |
| A3710 |  | ENCELIA CANESCEN GIRASOL SILVESTRE (0.20m a 0.30m) | 1d | 2023-11-16 | 2023-11-17 | A3700 SS | 74.5d | 129.5d |
| A3650 |  | PROSOPIS PALLIDA KUNTH ALGARROBO (0.80 a 1.50m) | 1d | 2023-12-12 | 2023-12-13 | A3570 | 48.5d | 0d |
| A3670 |  | ACACIA MACRACANTHA FAIQUE (0.80 a 1.50m) | 1d | 2023-12-12 | 2023-12-13 | A3650 SS | 48.5d | 0d |
| A3680 |  | PARKINSONIA ACULEATA AZOTE DE CRISTO (1.00 a 1.50 m) | 1d | 2023-12-12 | 2023-12-13 | A3670 SS | 48.5d | 103.5d |

| ID | WBS | Activity | Type | Duration | Start | Finish | Predecessors | Total float | Free float |
| --- | --- | --- | --- | --- | --- | --- | --- | --- | --- |
|  | 4 | **TRANSPORTE** |  |  | 2023-10-21 | 2023-12-13 |  |  |  |
| A3730 |  | Flete transporte terrestre para especies vegetales |  | 53d | 2023-10-21 | 2023-12-13 | A3620 SS | 48.5d | 103.5d |
|  | 5 | **ADQUISICION INSUMOS AGRICOLAS Y OTROS** |  |  | 2023-10-21 | 2023-12-13 |  |  |  |
| A3740 |  | COMPOST SACO 35kg |  | 53d | 2023-10-21 | 2023-12-13 | A3620 SS | 48.5d | 0d |
| A3750 |  | AZUFRE SACO 25kg |  | 53d | 2023-10-21 | 2023-12-13 | A3740 SS | 48.5d | 0d |
| A3760 |  | YESO SACO 40kg |  | 53d | 2023-10-21 | 2023-12-13 | A3750 SS | 48.5d | 0d |
| A3770 |  | NPK 10:30:10 SACO DE 50kg |  | 53d | 2023-10-21 | 2023-12-13 | A3760 SS | 48.5d | 0d |
| A3780 |  | NPK 20:20:20 SACO DE 50kg |  | 53d | 2023-10-21 | 2023-12-13 | A3770 SS | 48.5d | 0d |
| A3790 |  | TUTORES EUCALIPTO 2.5m |  | 53d | 2023-10-21 | 2023-12-13 | A3780 SS | 48.5d | 0d |
| A3800 |  | SOGA DE YUTE 5/64 DE 58m |  | 53d | 2023-10-21 | 2023-12-13 | A3790 SS | 48.5d | 0d |
| A3810 |  | PITON CONTRA INCENDIO PARA ADAPTACION DE MANGUERA DE CISTERNA |  | 3d | 2023-10-21 | 2023-10-24 | A3800 SS | 98.5d | 153.5d |
|  | 6 | **INSTALACION DE PLANTONES (Incluye colocacion de sustrato, tierra del lugar,** |  |  | 2023-10-22 | 2023-12-15 |  |  |  |
| A3870 |  | SENNA MULTIGLANDULOSA MUTUY (0.60 a 0.80m) |  | 28d | 2023-10-22 | 2023-11-19 | A3620 SS+1d | 72.5d | 127.5d |
| A3880 |  | ENCELIA CANESCEN GIRASOL SILVESTRE (0.20m a 0.30m) |  | 28d | 2023-10-22 | 2023-11-19 | A3630 SS+1d | 72.5d | 127.5d |
| A3820 |  | PROSOPIS PALLIDA KUNTH ALGARROBO (0.80 a 1.50m) |  | 28d | 2023-11-17 | 2023-12-15 | A3570 SS+1d | -43.5d | 0d |
| A3840 |  | ACACIA MACRACANTHA FAIQUE (0.80 a 1.50m) |  | 28d | 2023-11-17 | 2023-12-15 | A3590 SS+1d | 46.5d | 101.5d |
| A3850 |  | PARKINSONIA ACULEATA AZOTE DE CRISTO (1.00 a 1.50 m) |  | 28d | 2023-11-17 | 2023-12-15 | A3600 SS+1d | 46.5d | 101.5d |
|  | 7 | **NSTALACIÓN DE ALCORQUES** |  |  | 2023-11-17 | 2023-12-14 |  |  |  |
| A3900 |  | ALCORQUES DE PIEDRA DE CANTO RODADO PARA ARBOLES |  | 27.25d | 2023-11-17 | 2023-12-14 | A3820 SS | 47.25d | 102.25d |
|  | 8 | **RIEGO DE ESPECIES 12 MESES ( instalacion+establecimiento)** |  |  | 2023-12-15 | 2024-03-14 |  |  |  |
| A3910 |  | Riego por inundación, mediante camión cisterna con mangera adaptada con piton |  | 90d | 2023-12-15 | 2024-03-14 | A3820 | -43.5d | 0d |
|  | 9 | **MANTENIMIENTO PREVENTIVO PARA ESTABLECIMIENTO DE ESPECIE (12** |  |  | 2023-12-15 | 2024-03-14 |  |  |  |
| A3920 |  | MANO DE OBRA + PODA + REMOCION, DESMALEZADO, RECALCE Y |  | 90d | 2023-12-15 | 2024-03-14 | A3910 SS | -43.5d | 11.5d |
|  | 7 | **FIN)** |  |  | 2024-03-25 | 2024-03-25 |  |  |  |
| A4360 |  | FIN | milestone | 0d | 2024-03-25 | 2024-03-25 | A2000 FF | -55d | 0d |
